# Final

Schedule from MS Project, 2012-05-13 to 2015-09-17.

## Calendars

- LLAMA COCHABAMBA: Mon-Sun 09:00-13:00, 15:00-19:00.
- CAL_CHOTA-HUALGAYOC: Mon-Sun 09:00-13:00, 15:00-19:00.

## Schedule

| ID | WBS | Task | Type | Duration | Start | Finish | Predecessors | Total slack | Constraint | Calendar | Text1 |
| --- | --- | --- | --- | --- | --- | --- | --- | --- | --- | --- | --- |
| 1 | 1 | **CARRETERA CHOTA-BAMBAMARCA-HUALGAYOC** |  | 1223d | 2012-05-13 | 2015-09-17 |  | 0d |  | LLAMA COCHABAMBA |  |
| 2 | 1.1 | INICIO | milestone | 0d | 2012-05-13 | 2012-05-13 |  | 0d |  | LLAMA COCHABAMBA |  |
| 3 | 1.2 | **OBRAS PRELIMINARES** |  | 1223d | 2012-05-13 | 2015-09-17 |  | 0d |  | LLAMA COCHABAMBA | 1.00 |
| 4 | 1.2.1 | Movilizacion y desmovilizacion de Equipos |  | 787d | 2012-05-13 | 2015-09-17 | 2, 6FF | 0d | start no earlier than 2012-05-13 | LLAMA COCHABAMBA | 101.A |
| 5 | 1.2.2 | Topografia y Georeferenciacion |  | 225d | 2012-05-13 | 2013-01-31 | 2SS, 4SS | 0d | start no earlier than 2012-05-13 | LLAMA COCHABAMBA | 102.A |
| 6 | 1.2.3 | Mantenimiento de Transito y Seguridad Vial |  | 1124d | 2012-05-13 | 2015-09-17 | 2SS | 0d | start no earlier than 2012-05-13 | LLAMA COCHABAMBA | 103.A |
| 7 | 1.2.4 | Accesos a Canteras, Botaderos, Plantas de Proceso y Fuente de Agua. Sin explosivos |  | 695d | 2012-08-01 | 2014-09-15 | 4SS, 2SS, 5SS+80d | 0d | start no earlier than 2012-08-01 | LLAMA COCHABAMBA | 107.A |
| 8 | 1.3 | **MOVIMIENTO DE TIERRRA** |  | 1080d | 2012-08-16 | 2015-07-31 |  | 0d |  | LLAMA COCHABAMBA | 2.00 |
| 9 | 1.3.1 | Desbroce y limpieza en zonas no boscosas |  | 989d | 2012-08-16 | 2015-06-30 | 2SS+95d, 7FF | 0d | start no earlier than 2012-08-16 | LLAMA COCHABAMBA | 201.B |
| 10 | 1.3.2 | Corte en material suelto |  | 989d | 2012-08-16 | 2015-06-30 | 2SS+95d, 9FS-1049d | 0d | start no earlier than 2012-08-16 | LLAMA COCHABAMBA | 205.A |
| 11 | 1.3.3 | Corte en roca suelta |  | 989d | 2012-08-16 | 2015-06-30 | 10SS | 0d | start no earlier than 2012-08-16 | LLAMA COCHABAMBA | 205.B |
| 12 | 1.3.4 | Corte en roca fija |  | 912d | 2012-11-01 | 2015-06-30 | 10SS+77d | 0d | start no earlier than 2012-11-01 | LLAMA COCHABAMBA | 205.C |
| 13 | 1.3.5 | Remocion de derrumbes |  | 515d | 2012-09-16 | 2014-07-15 | 9SS+31d | 429d | start no earlier than 2012-09-16 | LLAMA COCHABAMBA | 206 |
| 14 | 1.3.6 | Perfilado y compactado en zona de corte |  | 396d | 2014-07-01 | 2015-07-31 | 10SS+654d, 12FF+31d | 0d | start no earlier than 2014-07-01 | LLAMA COCHABAMBA | 207.A |
| 15 | 1.3.7 | Conformacion en terraplenes con material propio |  | 638d | 2013-11-01 | 2015-07-31 | 10SS+442d, 11FF+31d, 12FF+31d | 0d | start no earlier than 2013-11-01 | LLAMA COCHABAMBA | 210.A |
| 16 | 1.3.8 | Conformacion en terraplenes con material de cantera |  | 716d | 2013-08-15 | 2015-07-31 | 15SS-78d | 0d | start no earlier than 2013-08-15 | LLAMA COCHABAMBA | 210.B |
| 17 | 1.3.9 | Mejoramiento de suelo a nivel de subrasante |  | 716d | 2013-08-15 | 2015-07-31 | 16SS, 18FF | 0d | start no earlier than 2013-08-15 | LLAMA COCHABAMBA | 220.B |
| 18 | 1.3.10 | Material Seleccionado para Terraplen / Relleno |  | 716d | 2013-08-15 | 2015-07-31 | 7FS-397d | 0d | start no earlier than 2013-08-15 |  |  |
| 19 | 1.4 | **SUB BASE Y BASES** |  | 427d | 2014-07-01 | 2015-08-31 |  | 0d |  | LLAMA COCHABAMBA | 3.00 |
| 20 | 1.4.1 | Sub Base Granular |  | 273d | 2014-11-16 | 2015-08-15 | 17FF+15d, 14FF+15d, 10FF+46d, 11FF+46d, 12FF+46d, 21 | 0d | start no earlier than 2014-11-16 | LLAMA COCHABAMBA | 303.A |
| 21 | 1.4.2 | Sub Base Granular - Adic. N° 05 |  | 138d | 2014-07-01 | 2014-11-15 | 15SS+242d, 16SS+320d | 0d | start no earlier than 2014-07-01 |  |  |
| 22 | 1.4.3 | Base Granular |  | 279d | 2014-11-26 | 2015-08-31 | 106FF, 23, 20FF+15d | 0d | start no earlier than 2014-11-26 | LLAMA COCHABAMBA | 305.A |
| 23 | 1.4.4 | Base Granular - Adic. N° 05 |  | 133d | 2014-07-16 | 2014-11-25 | 21SS+15d | 0d | start no earlier than 2014-07-16 |  |  |
| 24 | 1.5 | **PAVIMENTO ASFALTICOS** |  | 413d | 2014-08-01 | 2015-09-17 |  | 0d |  | LLAMA COCHABAMBA | 4.00 |
| 25 | 1.5.1 | Imprimacion asfaltica |  | 286d | 2014-12-06 | 2015-09-17 | 30FF, 26, 22FF+17d | 0d | start no earlier than 2014-12-06 | LLAMA COCHABAMBA | 401.A |
| 26 | 1.5.2 | Inmprimacion Asfaltica - Adic. N° 05 |  | 127d | 2014-08-01 | 2014-12-05 | 21SS+31d, 23SS+16d | 0d | start no earlier than 2014-08-01 |  |  |
| 27 | 1.5.3 | Pavimento Concreto Asfaltico Caliente (MAC) |  | 266d | 2014-12-26 | 2015-09-17 | 293FF, 254FF, 147FF, 195FF, 237FF, 170FF, 243FF, 276FF, 25FF, 32FF, 282FF, 317FF, 28, 200FF | 0d | start no earlier than 2014-12-26 | LLAMA COCHABAMBA | 410.A |
| 28 | 1.5.4 | Pavimento Concreto Asfaltico Caliente (MAC) - Adic. N° 05 |  | 147d | 2014-08-01 | 2014-12-25 | 26SS | 0d | start no earlier than 2014-08-01 |  |  |
| 29 | 1.5.5 | Cemento asfaltico de penetracion 85-100 |  | 413d | 2014-08-01 | 2015-09-17 | 2SS+810d | 0d | start no earlier than 2014-08-01 | LLAMA COCHABAMBA | 420.C |
| 30 | 1.5.6 | Asfalto diluido tipo MC-30 |  | 413d | 2014-08-01 | 2015-09-17 | 2SS+810d | 0d | start no earlier than 2014-08-01 | LLAMA COCHABAMBA | 422.A |
| 31 | 1.5.7 | Filler mineral (Cal hidratada) |  | 413d | 2014-08-01 | 2015-09-17 | 29FF | 0d | start no earlier than 2014-08-01 | LLAMA COCHABAMBA | 423.A |
| 32 | 1.5.8 | Aditivo mejorador de adherencia |  | 413d | 2014-08-01 | 2015-09-17 | 31FF | 0d | start no earlier than 2014-08-01 | LLAMA COCHABAMBA | 424.A |

| ID | WBS | Task | Type | Duration | Start | Finish | Predecessors | Total slack | Free slack | Constraint | Calendar | Text1 |
| --- | --- | --- | --- | --- | --- | --- | --- | --- | --- | --- | --- | --- |
| 33 | 1.6 | **OBRAS DE ARTE Y DRENAJE** |  | 1097d | 2012-09-16 | 2015-09-17 |  | 0d |  |  | LLAMA COCHABAMBA | 6.00 |
| 34 | 1.6.1 | Excavacion no clasificada para estructuras |  | 891d | 2012-09-16 | 2015-05-15 | 10SS+31d | 0d |  | start no earlier than 2012-09-16 | LLAMA COCHABAMBA | 601.A |
| 35 | 1.6.2 | Relleno para estructuras con material de prestamo |  | 891d | 2012-11-16 | 2015-07-15 | 34SS+61d, 39FF+257d, 50FF+15d, 51FF+15d, 52FF+15d, 55FF+15d, 76FF, 84FF, 90FF, 91FF, 81FF, 40FF+257d, 48FF+349d, 38FF, 37FF, 43FF, 45FF, 46FF, 53FF, 54FF, 56FF, 57FF, 60FF, 61FF, 80FF, 82FF | 0d |  | start no earlier than 2012-11-16 | LLAMA COCHABAMBA | 605.A |
| 36 | 1.6.3 | Concreto Clase C (f'c=280 kg/cm2) | milestone | 0d | 2013-10-01 | 2013-10-01 |  | 717d |  | start no earlier than 2013-10-01 | LLAMA COCHABAMBA | 610.C |
| 37 | 1.6.4 | Concreo Clase C (f'c=280 kg/cm2) - Adic. N° 07 |  | 457d | 2013-10-01 | 2014-12-31 | 34SS+380d | 196d |  | start no earlier than 2013-10-01 |  |  |
| 38 | 1.6.5 | Concreto Clase D (f'c=210 kg/cm2) |  | 799d | 2013-02-01 | 2015-06-30 | 34SS+138d, 7FS-592d | 0d |  | start no earlier than 2013-02-01 | LLAMA COCHABAMBA | 610.D |
| 39 | 1.6.6 | Concreto Clase D (f'c=210 kg/cm2) - Adic. N° 05 |  | 335d | 2013-12-01 | 2014-10-31 | 38SS+303d | 0d |  | start no earlier than 2013-12-01 |  |  |
| 40 | 1.6.7 | Concreto Clase D (f'c=210 kg/cm2) - Adic. N° 07 |  | 396d | 2013-10-01 | 2014-10-31 | 38SS+242d, 49FF+31d | 0d |  | start no earlier than 2013-10-01 |  |  |
| 41 | 1.6.8 | Concreto Clase E (f'c=175 kg/cm2) |  | 288d | 2014-09-16 | 2015-06-30 | 42FS-30d | 15d | 0d | start no earlier than 2014-09-16 | LLAMA COCHABAMBA | 610.E |
| 42 | 1.6.9 | Concreto Clase E (f'c=175 kg/cm2) - Adic. N° 05 |  | 153d | 2014-05-16 | 2014-10-15 | 34SS+607d | 15d | 0d | start no earlier than 2014-05-16 |  |  |
| 43 | 1.6.10 | Concreto Clase E (f'c=175 kg/cm2) - Adic. N° 07 |  | 30d | 2014-09-01 | 2014-09-30 | 42SS+108d | 288d |  | start no earlier than 2014-09-01 |  |  |
| 44 | 1.6.11 | Concreto Clase G (f'c=175 kg/cm2 + 30%PM) |  | 789d | 2013-02-01 | 2015-06-30 | 34SS+138d, 41FF | 15d | 0d | start no earlier than 2013-02-01 | LLAMA COCHABAMBA | 610.G |
| 45 | 1.6.12 | Concreo Clase G (f''c=175 kg/cm2 + 30%PM) - Adic. N° 05 |  | 319d | 2013-12-01 | 2014-10-15 | 44SS+303d | 273d |  | start no earlier than 2013-12-01 |  |  |
| 46 | 1.6.13 | Concreto Clase G (f'c=175 kg/cm2 + 30%PM) - Adic. N° 07 |  | 426d | 2013-10-01 | 2014-11-30 | 44SS+242d | 227d |  | start no earlier than 2013-10-01 |  |  |
| 47 | 1.6.14 | Concreto Clase H (f'c=100 kg/cm2) |  | 799d | 2013-02-01 | 2015-06-30 | 34SS+138d, 7FS-592d | 0d |  | start no earlier than 2013-02-01 | LLAMA COCHABAMBA | 610.H |
| 48 | 1.6.15 | Concreto Clase H (f'c=100 kg/cm2) - Adic. N° 05 |  | 243d | 2013-12-01 | 2014-07-31 | 47SS+303d | 0d |  | start no earlier than 2013-12-01 |  |  |
| 49 | 1.6.16 | Concreto Clase H (f'c=100 kg/cm2) - Adic. N° 07 |  | 365d | 2013-10-01 | 2014-09-30 | 47SS+242d | 0d |  | start no earlier than 2013-10-01 |  |  |
| 50 | 1.6.17 | Encofrado y desencofrado en seco |  | 799d | 2013-02-01 | 2015-06-30 | 34SS+138d | 0d |  | start no earlier than 2013-02-01 | LLAMA COCHABAMBA | 612.A |
| 51 | 1.6.18 | Acero de refuerzo Fy= 4200 kg/cm2 |  | 799d | 2013-02-01 | 2015-06-30 | 34SS+107d, 50SS | 0d |  | start no earlier than 2013-02-01 | LLAMA COCHABAMBA | 615 |
| 52 | 1.6.19 | Tuberia corrugada de acero galvanizado circular de 0.90m de diámetro |  | 861d | 2012-12-01 | 2015-06-30 | 34SS+76d | 0d |  | start no earlier than 2012-12-01 | LLAMA COCHABAMBA | 622.B |
| 53 | 1.6.20 | Tuberia corrugada de acero galvanizado circular de 0.90m de diámetro - Adic. N° 05 |  | 335d | 2013-12-01 | 2014-10-31 | 52SS+365d | 257d |  | start no earlier than 2013-12-01 |  |  |
| 54 | 1.6.21 | Tuberia corrugada de acero galvanizado circular de 0.90m de diametro - Adic. N° 07 |  | 153d | 2014-04-16 | 2014-09-15 | 52SS+427d | 303d |  | start no earlier than 2014-04-16 |  |  |
| 55 | 1.6.22 | Tuberia corrugada de acero galvanizado circular de 1.20m de diámetro |  | 861d | 2012-12-01 | 2015-06-30 | 34SS+76d, 52FF | 0d |  | start no earlier than 2012-12-01 | LLAMA COCHABAMBA | 622.C |
| 56 | 1.6.23 | Tuberia corrugada de acero galvanizado circular de 1.20m de diámetro - Adic. N° 05 |  | 304d | 2013-12-01 | 2014-09-30 | 55SS+365d | 288d |  | start no earlier than 2013-12-01 |  |  |
| 57 | 1.6.24 | Tuberia corrugada de acero galvanizado circular de 1.20m de diametro - Adic. N° 07 |  | 92d | 2014-07-01 | 2014-09-30 | 55SS+577d | 288d |  | start no earlier than 2014-07-01 |  |  |
| 58 | 1.6.25 | Tuberia corrugada de acero galvanizado circular de 1.50m de diámetro |  | 242d | 2014-11-01 | 2015-06-30 | 55FF-166d, 59 | 79d | 0d | start no earlier than 2014-11-01 | LLAMA COCHABAMBA | 622.D |
| 59 | 1.6.26 | Tuberia corrugada de acero galvanizado circular de 1.50m de diámetro - Adic. N° 05 |  | 335d | 2013-12-01 | 2014-10-31 | 34SS+441d | 79d | 0d | start no earlier than 2013-12-01 |  |  |
| 60 | 1.6.27 | Tuberia corrugada de acero galvanizado circular de 1.50m de diametro - Adic. N° 07 |  | 31d | 2013-10-01 | 2013-10-31 | 34SS+380d | 622d |  | start no earlier than 2013-10-01 |  |  |
| 61 | 1.6.28 | Arco Perfil Bajo Modelo 39SA8 |  | 406d | 2013-04-01 | 2014-10-31 | 34SS+197d, 58FS-821d | 257d |  | start no earlier than 2013-04-01 | LLAMA COCHABAMBA | 630.A |
| 62 | 1.6.29 | Cunetas triangulares revestidas con concreto tipo 1 |  | 155d | 2015-04-16 | 2015-09-17 | 27SS+111d | 0d |  | start no earlier than 2015-04-16 | LLAMA COCHABAMBA | 635.A |
| 63 | 1.6.30 | Cunetas triangulares revestidas con concreto tipo 1 - Adic. N° 05 |  | 304d | 2014-10-01 | 2015-07-31 | 28SS+61d | 0d |  | start no earlier than 2014-10-01 |  |  |
| 64 | 1.6.31 | Cunetas triangulares revestidas con concreto tipo 1 - Adic. N° 07 |  | 352d | 2014-10-01 | 2015-09-17 | 28SS+61d | 0d |  | start no earlier than 2014-10-01 |  |  |
| 65 | 1.6.32 | Cunetas rectangulares revestidas con concreto tipo 2 |  | 30d | 2015-06-01 | 2015-06-30 | 66FS-30d | 79d |  | start no earlier than 2015-06-01 | LLAMA COCHABAMBA | 635.B |
| 66 | 1.6.33 | Cunetas rectangulares revestidas con concreto tipo 2 - Adic. N° 05 |  | 30d | 2015-06-01 | 2015-06-30 | 28SS+304d | 79d | 0d | start no earlier than 2015-06-01 |  |  |
| 67 | 1.6.34 | Cunetas revestidas con concreto tipo 3 |  | 186d | 2015-03-16 | 2015-09-17 | 68 | 0d |  | start no earlier than 2015-03-16 | LLAMA COCHABAMBA | 635.C |
| 68 | 1.6.35 | Cunetas revestidas con concreto tipo 3 - Adic. N° 05 |  | 166d | 2014-10-01 | 2015-03-15 | 28SS+61d | 0d |  | start no earlier than 2014-10-01 |  |  |
| 69 | 1.6.36 | Cunetas revestidas con concreto tipo 3 - Adic. N° 07 |  | 352d | 2014-10-01 | 2015-09-17 | 28SS+61d | 0d |  | start no earlier than 2014-10-01 |  |  |
| 70 | 1.6.37 | Emboquillado de piedra e=0.15m |  | 260d | 2015-01-01 | 2015-09-17 |  | 0d |  | start no earlier than 2015-01-01 | LLAMA COCHABAMBA | 640.A |
| 71 | 1.6.38 | Emboquillado de piedra e=0.15m - Adic. N° 05 |  | 442d | 2014-05-16 | 2015-07-31 |  | 48d |  | start no earlier than 2014-05-16 |  |  |
| 72 | 1.6.39 | Emboquillado de piedra e=0.15m - Adic. N° 07 |  | 367d | 2014-09-16 | 2015-09-17 |  | 0d |  | start no earlier than 2014-09-16 |  |  |
| 73 | 1.6.40 | Emboquillado de piedra e=0.35m | milestone | 0d | 2015-04-16 | 2015-04-16 |  | 155d |  | start no earlier than 2015-04-16 | LLAMA COCHABAMBA | 640.B |
| 74 | 1.6.41 | Emboquillado de piedra e=0.35m - Adic. N° 07 |  | 91d | 2015-04-16 | 2015-07-15 |  | 0d |  | start no earlier than 2015-04-16 |  |  |
| 75 | 1.6.42 | Demolición de estructuras de concreto |  | 831d | 2012-12-01 | 2015-05-31 | 10SS+107d | 109d |  | start no earlier than 2012-12-01 | LLAMA COCHABAMBA | 645 |
| 76 | 1.6.43 | Filtro Drenante |  | 350d | 2014-07-16 | 2015-06-30 | 92FF | 15d |  | start no earlier than 2014-07-16 | LLAMA COCHABAMBA | 647 |
| 77 | 1.6.44 | Filtro Drenante - Adic. N° 05 |  | 297d | 2013-10-23 | 2014-08-15 | 34SS+402d | 15d | 0d | start no earlier than 2013-10-23 |  |  |
| 78 | 1.6.45 | Filtro Drenante - Adic. N° 07 |  | 320d | 2014-05-16 | 2015-03-31 | 83FF-91d, 34SS+607d | 106d | 91d | start no earlier than 2014-05-16 |  |  |
| 79 | 1.6.46 | Tubo de PVC-SAP Clase 10 D=3" |  | 546d | 2014-01-01 | 2015-06-30 | 44FF, 77SS+70d | 15d | 0d | start no earlier than 2014-01-01 | LLAMA COCHABAMBA | 649.B |
| 80 | 1.6.47 | Tubo de PVC-SAP Clase 10 D=4 " |  | 546d | 2014-01-01 | 2015-06-30 | 79SS, 44FF | 15d |  | start no earlier than 2014-01-01 | LLAMA COCHABAMBA | 649.C |
| 81 | 1.6.48 | Tubo de PVC-SAP Clase 10 D=6 " con perforacion |  | 334d | 2014-08-01 | 2015-06-30 | 82SS+282d | 15d |  | start no earlier than 2014-08-01 | LLAMA COCHABAMBA | 649.D |
| 82 | 1.6.49 | Tubo de PVC-SAP Clase 10 D=6" con perforacion - Adic. N° 05 |  | 343d | 2013-10-23 | 2014-09-30 | 34SS+402d | 15d | 0d | start no earlier than 2013-10-23 |  |  |
| 83 | 1.6.50 | Tubo de PVC-SAP Clase 10 D=6" con perforacion - Adic. N° 07 |  | 350d | 2014-07-16 | 2015-06-30 | 34SS+668d | 15d | 0d | start no earlier than 2014-07-16 |  |  |
| 84 | 1.6.51 | Tubo de PVC-SAP Clase 10 D=6 " sin perforacion |  | 395d | 2014-06-01 | 2015-06-30 | 82SS+221d | 15d | 0d | start no earlier than 2014-06-01 | LLAMA COCHABAMBA | 649.E |
| 85 | 1.6.52 | Tubo de PVC-SAP Clase 10 D=2" - Agua Potable |  | 62d | 2014-07-01 | 2014-08-31 | 87SS+30d | 321d | 0d | start no earlier than 2014-07-01 |  |  |
| 86 | 1.6.53 | Tubo de PVC-SAP Clase 10 D=1 1/2"- Agua potable |  | 92d | 2014-08-01 | 2014-10-31 | 85FS-31d | 321d |  | start no earlier than 2014-08-01 |  |  |
| 87 | 1.6.54 | Tubo de PVC-SAP Clase 10 D=1"- Agua potable |  | 122d | 2014-06-01 | 2014-09-30 | 84SS | 321d | 0d | start no earlier than 2014-06-01 |  |  |
| 88 | 1.6.55 | Tubo de PVC-SAP Clase 10 D=3/4"- Agua potable |  | 61d | 2014-09-01 | 2014-10-31 | 87FS-30d | 321d |  | start no earlier than 2014-09-01 |  |  |
| 89 | 1.6.56 | Tubo de PVC-SAP Clase 10 D= 1/2"- Agua potable |  | 122d | 2014-06-01 | 2014-09-30 | 84SS | 352d |  | start no earlier than 2014-06-01 |  |  |
| 90 | 1.6.57 | Tubo Metalico galvanizado 1 1/2 " |  | 350d | 2014-07-16 | 2015-06-30 | 83SS | 15d |  | start no earlier than 2014-07-16 | LLAMA COCHABAMBA | 649.F |
| 91 | 1.6.58 | Geotextil clase 2 para drenaje |  | 924d | 2012-09-16 | 2015-06-30 | 100SS | 15d |  | start no earlier than 2012-09-16 | LLAMA COCHABAMBA | 650.A |
| 92 | 1.6.59 | Material Granular para subdren |  | 319d | 2014-08-16 | 2015-06-30 | 93FS-46d, 94FF | 15d | 0d | start no earlier than 2014-08-16 | LLAMA COCHABAMBA | 652.A |
| 93 | 1.6.60 | Material Granular para subdren - Adic. N° 05 |  | 343d | 2013-10-23 | 2014-09-30 | 82SS | 15d | 0d | start no earlier than 2013-10-23 |  |  |
| 94 | 1.6.61 | Material Granular para subdren - Adic. N° 07 |  | 350d | 2014-07-16 | 2015-06-30 | 83SS, 78FF | 15d | 0d | start no earlier than 2014-07-16 |  |  |
| 95 | 1.6.62 | Zanja de drenaje |  | 352d | 2014-10-01 | 2015-09-17 | 63SS | 0d |  | start no earlier than 2014-10-01 | LLAMA COCHABAMBA | 658.A |
| 96 | 1.6.63 | Junta de construccion |  | 365d | 2014-07-16 | 2015-07-15 | 44FF+15d | 64d |  | start no earlier than 2014-07-16 | LLAMA COCHABAMBA | 659.A |
| 97 | 1.6.64 | Zanja de coronacion revestida |  | 166d | 2015-02-16 | 2015-07-31 | 98FS+138d | 0d |  | start no earlier than 2015-02-16 | LLAMA COCHABAMBA | 663.A |
| 98 | 1.6.65 | Zanja de coronacion revestida - Adic. N° 05 |  | 92d | 2014-07-01 | 2014-09-30 | 34SS+653d | 0d |  | start no earlier than 2014-07-01 |  |  |
| 99 | 1.6.66 | Zanja de coronacion revestida - Adic. N° 07 |  | 122d | 2014-06-01 | 2014-09-30 | 34SS+623d | 352d |  | start no earlier than 2014-06-01 |  |  |
| 100 | 1.6.67 | Gaviones rectangulares Tipo A, Tipo B |  | 761d | 2012-09-16 | 2014-12-15 | 34SS | 0d |  | start no earlier than 2012-09-16 | LLAMA COCHABAMBA | 664 |
| 101 | 1.6.68 | Gaviones Tipo Colchon tipo D |  | 413d | 2012-10-16 | 2014-01-31 | 100SS+30d | 0d |  | finish no earlier than 2014-01-31 | LLAMA COCHABAMBA | 665 |
| 102 | 1.6.69 | Enrocado |  | 638d | 2013-10-01 | 2015-06-30 | 101SS+350d | 79d |  | start no earlier than 2013-10-01 | LLAMA COCHABAMBA | 666 |

| ID | WBS | Task | Duration | Start | Finish | Predecessors | Total slack | Constraint | Calendar | Text1 |
| --- | --- | --- | --- | --- | --- | --- | --- | --- | --- | --- |
| 103 | 1.6.70 | Encausamiento de quebradas | 427d | 2014-07-01 | 2015-08-31 | 34FF+108d | 17d | start no earlier than 2014-07-01 | LLAMA COCHABAMBA | 670.A |
| 104 | 1.7 | **TRANSPORTES** | 1128d | 2012-08-16 | 2015-09-17 |  | 0d |  | LLAMA COCHABAMBA | 7.00 |
| 105 | 1.7.1 | Transporte de material granular para D < = 1km | 747d | 2013-08-15 | 2015-08-31 | 16SS | 0d | start no earlier than 2013-08-15 | LLAMA COCHABAMBA | 700.A |
| 106 | 1.7.2 | Transporte de material granular para D > 1km | 747d | 2013-08-15 | 2015-08-31 | 105SS | 0d | start no earlier than 2013-08-15 | LLAMA COCHABAMBA | 700.B |
| 107 | 1.7.3 | Transporte de mezcla asfaltica para D < = 1km | 413d | 2014-08-01 | 2015-09-17 | 28SS | 0d | start no earlier than 2014-08-01 | LLAMA COCHABAMBA | 700.C |
| 108 | 1.7.4 | Transporte de mezcla asfaltica para D > 1km | 413d | 2014-08-01 | 2015-09-17 | 107SS | 0d | start no earlier than 2014-08-01 | LLAMA COCHABAMBA | 700.D |
| 109 | 1.7.5 | Transporte de material excedente a DME para D < = 1km | 989d | 2012-08-16 | 2015-06-30 | 10SS, 34FF | 0d | start no earlier than 2012-08-16 | LLAMA COCHABAMBA | 700.G |
| 110 | 1.7.6 | Transporte de material excedente a DME para D > 1km | 989d | 2012-08-16 | 2015-06-30 | 109SS | 0d | start no earlier than 2012-08-16 | LLAMA COCHABAMBA | 700.H |
| 111 | 1.8 | **SEÑALIZACION Y SEGURIDAD VIAL** | 125d | 2015-05-16 | 2015-09-17 |  | 0d |  | LLAMA COCHABAMBA | 8.00 |
| 112 | 1.8.1 | Señal preventiva (0.75x0.75m) | 125d | 2015-05-16 | 2015-09-17 | 27FS-125d | 0d | start no earlier than 2015-05-16 | LLAMA COCHABAMBA | 801.E |
| 113 | 1.8.2 | Señal reglamentaria octogonal R-1 (0.60x0.60m) | 125d | 2015-05-16 | 2015-09-17 | 112FS-125d | 0d | start no earlier than 2015-05-16 | LLAMA COCHABAMBA | 802.C |
| 114 | 1.8.3 | Señal reglamentaria triangular R-2 (0.75m de lado) | 109d | 2015-06-01 | 2015-09-17 | 113FS-109d | 0d | start no earlier than 2015-06-01 | LLAMA COCHABAMBA | 802.F |
| 115 | 1.8.4 | Señal reglamentaria rectangular (0.80x1.20m) | 125d | 2015-05-16 | 2015-09-17 | 114FS-125d | 0d | start no earlier than 2015-05-16 | LLAMA COCHABAMBA | 802.J |
| 116 | 1.8.5 | Señal informativa | 125d | 2015-05-16 | 2015-09-17 | 115FS-125d | 0d | start no earlier than 2015-05-16 | LLAMA COCHABAMBA | 803.C |
| 117 | 1.8.6 | Señal informativa ambiental | 125d | 2015-05-16 | 2015-09-17 | 116FS-125d | 0d | start no earlier than 2015-05-16 | LLAMA COCHABAMBA | 803.D |
| 118 | 1.8.7 | Postes de soporte de señales | 125d | 2015-05-16 | 2015-09-17 | 117FS-125d | 0d | start no earlier than 2015-05-16 | LLAMA COCHABAMBA | 804.A |
| 119 | 1.8.8 | Estructuras de soporte de señales tipo E-1 | 125d | 2015-05-16 | 2015-09-17 | 118FS-125d | 0d | start no earlier than 2015-05-16 | LLAMA COCHABAMBA | 804.B |
| 120 | 1.8.9 | Estructuras de soporte de señales tipo E-2 | 62d | 2015-07-01 | 2015-08-31 | 121SS+46d | 17d | start no earlier than 2015-07-01 | LLAMA COCHABAMBA | 804.C |
| 121 | 1.8.10 | Postes delineador | 125d | 2015-05-16 | 2015-09-17 | 119FS-125d | 0d | start no earlier than 2015-05-16 | LLAMA COCHABAMBA | 805.A |
| 122 | 1.8.11 | Marcas en el pavimento | 125d | 2015-05-16 | 2015-09-17 | 121FS-125d | 0d | start no earlier than 2015-05-16 | LLAMA COCHABAMBA | 810.A |
| 123 | 1.8.12 | Guardavia Metálica | 125d | 2015-05-16 | 2015-09-17 | 122FS-125d | 0d | start no earlier than 2015-05-16 | LLAMA COCHABAMBA | 820.A |
| 124 | 1.8.13 | Captafaros | 125d | 2015-05-16 | 2015-09-17 | 123FS-125d | 0d | start no earlier than 2015-05-16 | LLAMA COCHABAMBA | 825.A |
| 125 | 1.8.14 | Postes de kilometraje | 125d | 2015-05-16 | 2015-09-17 | 124FS-125d | 0d | start no earlier than 2015-05-16 | LLAMA COCHABAMBA | 830.A |
| 126 | 1.8.15 | Pintados de parapetos en muros y alcantarillas | 125d | 2015-05-16 | 2015-09-17 | 125FS-125d, 38FF+17d, 41FF+17d, 44FF+17d, 47FF+17d | 0d | start no earlier than 2015-05-16 | LLAMA COCHABAMBA | 840.A |
| 127 | 1.8.16 | Tachas delineadoras | 125d | 2015-05-16 | 2015-09-17 | 126FS-125d | 0d | start no earlier than 2015-05-16 | LLAMA COCHABAMBA | 850.A |
| 128 | 1.8.17 | Gibas lomo de toro | 125d | 2015-05-16 | 2015-09-17 | 127FS-125d | 0d | start no earlier than 2015-05-16 | LLAMA COCHABAMBA | 860.A |

| ID | WBS | Task | Type | Duration | Start | Finish | Predecessors | Total slack | Free slack | Constraint | Calendar | Text1 |
| --- | --- | --- | --- | --- | --- | --- | --- | --- | --- | --- | --- | --- |
| 129 | 1.9 | **PROTECCION AMBIENTAL** |  | 1223d | 2012-05-13 | 2015-09-17 |  | 0d |  |  | LLAMA COCHABAMBA | 9.00 |
| 130 | 1.9.1 | Retiro y almacenamiento de Topsoil |  | 968d | 2012-08-16 | 2015-06-30 | 10SS | 0d |  | start no earlier than 2012-08-16 | LLAMA COCHABAMBA | 901.B1 |
| 131 | 1.9.2 | Reposicion de Top-soil |  | 125d | 2015-05-16 | 2015-09-17 | 130FS-46d | 0d |  | start no earlier than 2015-05-16 | LLAMA COCHABAMBA | 901.B2 |
| 132 | 1.9.3 | Revegetacion |  | 276d | 2014-12-16 | 2015-09-17 | 131SS-152d | 0d |  | start no earlier than 2014-12-16 | LLAMA COCHABAMBA | 902.B |
| 133 | 1.9.4 | Deposito de material excedente |  | 987d | 2012-08-16 | 2015-06-30 | 10SS, 110FF, 163FF, 192FF, 213FF, 252FF, 291FF | 0d |  | start no earlier than 2012-08-16 | LLAMA COCHABAMBA | 906.A |
| 134 | 1.9.5 | Readecuacion ambiental de Canteras |  | 125d | 2015-05-16 | 2015-09-17 | 133FS-46d | 0d |  | start no earlier than 2015-05-16 | LLAMA COCHABAMBA | 907.A1 |
| 135 | 1.9.6 | Readecuacion ambiental de Plantas de Trituracion y Asfalto |  | 125d | 2015-05-16 | 2015-09-17 | 134SS | 0d |  | start no earlier than 2015-05-16 | LLAMA COCHABAMBA | 907.A2 |
| 136 | 1.9.7 | Readecuacion ambiental de Campamentos |  | 125d | 2015-05-16 | 2015-09-17 | 135SS | 0d |  | start no earlier than 2015-05-16 | LLAMA COCHABAMBA | 907.B1 |
| 137 | 1.9.8 | Readecuacion ambiental de Almacenes y Patio de Maquinas |  | 125d | 2015-05-16 | 2015-09-17 | 136SS | 0d |  | start no earlier than 2015-05-16 | LLAMA COCHABAMBA | 907.B2 |
| 138 | 1.9.9 | **PROGRAMA DE MONITOREO AMBIENTAL** |  | 1206d | 2012-05-13 | 2015-08-31 |  | 17d |  |  | LLAMA COCHABAMBA | 9.1 |
| 139 | 1.9.9.1 | Monitoreo de Calidad de Aire |  | 199d | 2012-05-13 | 2014-05-31 | 2SS | 474d |  | start no earlier than 2012-05-13 | LLAMA COCHABAMBA | 970.A |
| 140 | 1.9.9.2 | Monitoreo de Calidad de Agua |  | 350d | 2012-05-13 | 2015-08-31 | 2SS | 17d |  | start no earlier than 2012-05-13 | LLAMA COCHABAMBA | 970.B |
| 141 | 1.10 | **PUENTES Y PONTONES** |  | 942d | 2012-10-01 | 2015-04-30 |  | 140d |  |  | LLAMA COCHABAMBA | 11.00 |
| 142 | 1.10.1 | **PONTON MATEO** |  | 365d | 2013-08-01 | 2014-07-31 |  | 413d |  |  | LLAMA COCHABAMBA | 6.00 |
| 143 | 1.10.1.1 | Limpieza de Cauce y Encausamiento |  | 31d | 2014-03-01 | 2014-03-31 | 145FS+181d | 535d |  | start no earlier than 2014-03-01 | LLAMA COCHABAMBA | 670.B |
| 144 | 1.10.1.2 | Excavacion no clasificada para estructuras en seco |  | 31d | 2013-08-01 | 2013-08-31 | 10SS+350d | 413d | 0d | start no earlier than 2013-08-01 | LLAMA COCHABAMBA | 601.B |
| 145 | 1.10.1.3 | Excavacion no clasificada para estructuras bajo agua |  | 31d | 2013-08-01 | 2013-08-31 | 144FF | 413d | 0d | start no earlier than 2013-08-01 | LLAMA COCHABAMBA | 601.C |
| 146 | 1.10.1.4 | Relleno para estructuras con material de prestamo |  | 31d | 2014-03-01 | 2014-03-31 | 151FS+181d | 535d | 0d | start no earlier than 2014-03-01 | LLAMA COCHABAMBA | 605.A |
| 147 | 1.10.1.5 | Relleno para estructuras con material propio |  | 31d | 2014-03-01 | 2014-03-31 | 146FF | 535d | 0d | start no earlier than 2014-03-01 | LLAMA COCHABAMBA | 605.B |
| 148 | 1.10.1.6 | Concreto Clase H (f'c=100 kg/cm2) | milestone | 0d | 2013-08-01 | 2013-08-01 |  | 778d |  | start no earlier than 2013-08-01 | LLAMA COCHABAMBA | 610.H |
| 149 | 1.10.1.7 | Concreto Clase H 1(f'c=140 kg/cm2 + 30%PM) |  | 31d | 2013-08-01 | 2013-08-31 | 145FS-31d | 413d | 0d | start no earlier than 2013-08-01 | LLAMA COCHABAMBA | 610.H.1 |
| 150 | 1.10.1.8 | Concreto Clase D 1(f'c=210 kg/cm2 bajo agua) |  | 31d | 2013-08-01 | 2013-08-31 | 149FS-31d | 413d | 0d | start no earlier than 2013-08-01 | LLAMA COCHABAMBA | 610.D.1 |
| 151 | 1.10.1.9 | Concreto Clase D (f'c=210 kg/cm2) |  | 31d | 2013-08-01 | 2013-08-31 | 150FS-31d | 413d | 0d | start no earlier than 2013-08-01 | LLAMA COCHABAMBA | 610.D |
| 152 | 1.10.1.10 | Concreto Clase C (f'c=280 kg/cm2) |  | 31d | 2013-08-01 | 2013-08-31 | 155FS-31d, 151FF | 413d | 0d | start no earlier than 2013-08-01 | LLAMA COCHABAMBA | 610.C |
| 153 | 1.10.1.11 | Encofrado y desencofrado en seco |  | 31d | 2013-08-01 | 2013-08-31 | 149FS-31d | 413d | 0d | start no earlier than 2013-08-01 | LLAMA COCHABAMBA | 612.A |
| 154 | 1.10.1.12 | Encofrado y desencofrado bajo agua |  | 31d | 2013-08-01 | 2013-08-31 | 153FF | 413d | 0d | start no earlier than 2013-08-01 | LLAMA COCHABAMBA | 612.B |
| 155 | 1.10.1.13 | Encofrado y desencofrado caravista |  | 31d | 2013-08-01 | 2013-08-31 | 154FF, 156FF, 158FF | 413d | 0d | start no earlier than 2013-08-01 | LLAMA COCHABAMBA | 612.C |
| 156 | 1.10.1.14 | Acero de refuerzo Fy= 4200 kg/cm2 |  | 31d | 2013-08-01 | 2013-08-31 | 149FS-31d | 413d | 0d | start no earlier than 2013-08-01 | LLAMA COCHABAMBA | 615 |
| 157 | 1.10.1.15 | Falso puente |  | 31d | 2013-08-01 | 2013-08-31 | 151FS-31d | 413d | 0d | start no earlier than 2013-08-01 | LLAMA COCHABAMBA | 616 |
| 158 | 1.10.1.16 | Tubo de PVC-SAP, D=3 " x pieza |  | 31d | 2013-08-01 | 2013-08-31 | 157FS-31d | 413d | 0d | start no earlier than 2013-08-01 | LLAMA COCHABAMBA | 649.B |
| 159 | 1.10.1.17 | Perfilado y compactado para enrocado |  | 31d | 2014-03-01 | 2014-03-31 | 145FS+181d | 535d | 0d | start no earlier than 2014-03-01 | LLAMA COCHABAMBA | 207.A |
| 160 | 1.10.1.18 | Filtro drenante |  | 31d | 2014-03-01 | 2014-03-31 | 159FF, 147FF | 535d | 0d | start no earlier than 2014-03-01 | LLAMA COCHABAMBA | 647 |
| 161 | 1.10.1.19 | Enrocado |  | 31d | 2014-03-01 | 2014-03-31 | 160SS, 147FF, 159FS-59d | 535d |  | start no earlier than 2014-03-01 | LLAMA COCHABAMBA | 666 |
| 162 | 1.10.1.20 | Transporte de material excedente a DME para D < = 1km |  | 62d | 2013-08-01 | 2014-03-31 | 145SS | 456d | 0d | start no earlier than 2013-08-01 | LLAMA COCHABAMBA | 700.G |
| 163 | 1.10.1.21 | Transporte de material excedente a DME para D > 1km |  | 62d | 2013-08-01 | 2014-03-31 | 162SS | 456d |  | start no earlier than 2013-08-01 | LLAMA COCHABAMBA | 700.H |
| 164 | 1.10.1.22 | Guardavia Metálica |  | 31d | 2014-07-01 | 2014-07-31 | 152FS+303d | 413d |  | start no earlier than 2014-07-01 | LLAMA COCHABAMBA | 820.A |

| ID | WBS | Task | Duration | Start | Finish | Predecessors | Total slack | Free slack | Constraint | Calendar | Text1 |
| --- | --- | --- | --- | --- | --- | --- | --- | --- | --- | --- | --- |
| 165 | 1.10.2 | **PONTON TRANCAMAYO** | 243d | 2014-07-01 | 2015-02-28 |  | 201d |  |  | LLAMA COCHABAMBA | 7.00 |
| 166 | 1.10.2.1 | Limpieza de Cauce y Encausamiento | 62d | 2014-07-01 | 2014-08-31 | 10SS+684d | 201d | 0d | start no earlier than 2012-10-01 | LLAMA COCHABAMBA | 670.B |
| 167 | 1.10.2.2 | Excavacion no clasificada para estructuras en seco | 62d | 2014-07-01 | 2014-08-31 | 166FS-62d | 201d | 0d | start no earlier than 2012-10-01 | LLAMA COCHABAMBA | 601.B |
| 168 | 1.10.2.3 | Excavacion no clasificada para estructuras bajo agua | 62d | 2014-07-01 | 2014-08-31 | 167FF | 201d | 0d | start no earlier than 2012-10-01 | LLAMA COCHABAMBA | 601.C |
| 169 | 1.10.2.4 | Relleno para estructuras con material de prestamo | 61d | 2014-09-01 | 2014-10-31 | 172FS-30d | 321d | 0d | start no earlier than 2013-08-01 | LLAMA COCHABAMBA | 605.A |
| 170 | 1.10.2.5 | Relleno para estructuras con material propio | 61d | 2014-09-01 | 2014-10-31 | 169FF | 321d | 30d | start no earlier than 2013-08-01 | LLAMA COCHABAMBA | 605.B |
| 171 | 1.10.2.6 | Concreto Clase C (f'c=280 kg/cm2) | 92d | 2014-07-01 | 2014-09-30 | 179FS-92d, 172FF | 201d | 0d | start no earlier than 2014-02-01 | LLAMA COCHABAMBA | 610.C |
| 172 | 1.10.2.7 | Concreto Clase D (f'c=210 kg/cm2) | 92d | 2014-07-01 | 2014-09-30 | 173FS-92d | 201d | 0d | start no earlier than 2013-09-01 | LLAMA COCHABAMBA | 610.D |
| 173 | 1.10.2.8 | Concreto Clase D 1(f'c=210 kg/cm2 bajo agua) | 92d | 2014-07-01 | 2014-09-30 | 174FS-92d | 201d | 0d | start no earlier than 2013-09-01 | LLAMA COCHABAMBA | 610.D.1 |
| 174 | 1.10.2.9 | Concreto Clase H (f'c=100 kg/cm2) | 92d | 2014-07-01 | 2014-09-30 | 168FS-62d, 183FS-62d | 201d | 0d | start no earlier than 2013-08-01 | LLAMA COCHABAMBA | 610.H |
| 175 | 1.10.2.10 | Acabado de veredas | 61d | 2014-09-01 | 2014-10-31 | 171FS-30d | 321d | 0d | start no earlier than 2013-10-01 | LLAMA COCHABAMBA | 611.A |
| 176 | 1.10.2.11 | Bruñas rompe aguas | 61d | 2014-09-01 | 2014-10-31 | 175FF | 321d | 0d | start no earlier than 2012-10-01 | LLAMA COCHABAMBA | 611.B |
| 177 | 1.10.2.12 | Encofrado y desencofrado en seco | 92d | 2014-07-01 | 2014-09-30 | 174FS-92d | 201d | 0d | start no earlier than 2013-09-01 | LLAMA COCHABAMBA | 612.A |
| 178 | 1.10.2.13 | Encofrado y desencofrado bajo agua | 92d | 2014-07-01 | 2014-09-30 | 177FF | 201d | 0d | start no earlier than 2012-10-01 | LLAMA COCHABAMBA | 612.B |
| 179 | 1.10.2.14 | Encofrado y desencofrado caravista | 92d | 2014-07-01 | 2014-09-30 | 178FF, 180FF, 190FF | 201d | 0d | start no earlier than 2014-02-01 | LLAMA COCHABAMBA | 612.C |
| 180 | 1.10.2.15 | Acero de refuerzo Fy= 4200 kg/cm2 | 92d | 2014-07-01 | 2014-09-30 | 174FS-92d | 201d | 0d | start no earlier than 2012-10-01 | LLAMA COCHABAMBA | 615 |
| 181 | 1.10.2.16 | Baranda metalica (incluye fabricacion y pintura) | 61d | 2014-09-01 | 2014-10-31 | 176FF | 321d | 0d | start no earlier than 2012-10-01 | LLAMA COCHABAMBA | 615.C |
| 182 | 1.10.2.17 | Falso puente | 62d | 2014-07-01 | 2014-08-31 | 172FS-92d | 231d | 0d | start no earlier than 2012-10-01 | LLAMA COCHABAMBA | 616 |
| 183 | 1.10.2.18 | Demolición de estructuras de concreto | 62d | 2014-07-01 | 2014-08-31 | 166SS | 201d | 0d | start no earlier than 2012-10-01 | LLAMA COCHABAMBA | 645 |
| 184 | 1.10.2.19 | Tubo de PVC-SAP, D=3 " x pieza | 61d | 2014-08-01 | 2014-09-30 | 182FS-31d | 231d | 0d | start no earlier than 2012-10-01 | LLAMA COCHABAMBA | 649.B |
| 185 | 1.10.2.20 | Tubo de PVC-SAP, D=6 " | 61d | 2014-08-01 | 2014-09-30 | 184FF | 231d | 0d | start no earlier than 2012-10-01 | LLAMA COCHABAMBA | 619.E.1 |
| 186 | 1.10.2.21 | Fabricación y colocación de juntas de dilatación | 61d | 2014-08-01 | 2014-09-30 | 185FF | 231d | 0d | start no earlier than 2012-10-01 | LLAMA COCHABAMBA | 659 |
| 187 | 1.10.2.22 | Perfilado y compactado para enrocado | 92d | 2014-08-01 | 2014-10-31 | 168FS-31d | 321d | 0d | start no earlier than 2013-08-01 | LLAMA COCHABAMBA | 207.B |
| 188 | 1.10.2.23 | Filtro drenante | 92d | 2014-08-01 | 2014-10-31 | 187FF, 170FF-30d | 321d | 0d | start no earlier than 2013-07-01 | LLAMA COCHABAMBA | 647 |
| 189 | 1.10.2.24 | Enrocado | 92d | 2014-08-01 | 2014-10-31 | 188SS, 170FF-30d, 187FS-123d | 321d |  | start no earlier than 2014-05-01 | LLAMA COCHABAMBA | 666 |
| 190 | 1.10.2.25 | Apoyo de Neopreno (30x25x6.3) cm | 62d | 2014-07-01 | 2014-08-31 | 186FF-30d | 231d | 30d | start no earlier than 2012-10-01 | LLAMA COCHABAMBA | 680.C |
| 191 | 1.10.2.26 | Transporte de material excedente a DME para D < = 1km | 62d | 2014-07-01 | 2014-08-31 | 168SS | 303d | 0d | start no earlier than 2012-10-01 | LLAMA COCHABAMBA | 700.G |
| 192 | 1.10.2.27 | Transporte de material excedente a DME para D > 1km | 62d | 2014-07-01 | 2014-08-31 | 191SS | 303d |  | start no earlier than 2012-10-01 | LLAMA COCHABAMBA | 700.H |
| 193 | 1.10.2.28 | Guardavia Metálica | 61d | 2014-09-01 | 2014-10-31 | 181FF | 321d | 0d | start no earlier than 2012-10-01 | LLAMA COCHABAMBA | 820.A |
| 194 | 1.10.2.29 | Pintados de parapetos en muros y alcantarillas | 61d | 2014-09-01 | 2014-10-31 | 193FF | 321d |  | start no earlier than 2012-10-01 | LLAMA COCHABAMBA | 840.A |
| 195 | 1.10.2.30 | Riego de Liga | 28d | 2015-02-01 | 2015-02-28 | 171FS+123d | 201d |  | start no earlier than 2012-10-01 | LLAMA COCHABAMBA | 841 |

| ID | WBS | Task | Type | Duration | Start | Finish | Predecessors | Total slack | Free slack | Constraint | Calendar | Text1 |
| --- | --- | --- | --- | --- | --- | --- | --- | --- | --- | --- | --- | --- |
| 196 | 1.10.3 | **PUENTE POTRERO** |  | 456d | 2013-09-01 | 2014-11-30 |  | 291d |  |  | LLAMA COCHABAMBA | 8.00 |
| 197 | 1.10.3.1 | **SUBESTRUCTURA** |  | 212d | 2013-09-01 | 2014-03-31 |  | 291d |  |  | LLAMA COCHABAMBA | 8.01 |
| 198 | 1.10.3.1.1 | Excavacion no clasificada para estructuras en seco |  | 61d | 2013-09-01 | 2013-12-31 | 10SS+381d | 291d | 0d | start no earlier than 2012-08-01 | LLAMA COCHABAMBA | 601.B |
| 199 | 1.10.3.1.2 | Excavacion no clasificada para estructuras bajo agua |  | 61d | 2013-09-01 | 2014-03-31 | 198SS | 291d | 0d | start no earlier than 2013-08-25 | LLAMA COCHABAMBA | 601.C |
| 200 | 1.10.3.1.3 | Relleno para estructuras con material de prestamo |  | 62d | 2013-12-01 | 2014-03-31 | 203FS-31d | 535d |  | start no earlier than 2012-08-01 | LLAMA COCHABAMBA | 605.A |
| 201 | 1.10.3.1.4 | Relleno para estructuras con material propio | milestone | 0d | 2013-12-01 | 2013-12-01 |  | 656d |  | start no earlier than 2013-12-01 | LLAMA COCHABAMBA | 605.B |
| 202 | 1.10.3.1.5 | Concreto Clase D (f'c=210 kg/cm2) | milestone | 0d | 2013-12-01 | 2013-12-01 |  | 656d |  | start no earlier than 2013-12-01 | LLAMA COCHABAMBA | 610.D |
| 203 | 1.10.3.1.6 | Concreto Clase D2 (f'c=210 kg/cm2) - Adic. N° 08 |  | 31d | 2013-12-01 | 2013-12-31 | 205FS-31d, 210FS-31d | 291d | 0d |  |  |  |
| 204 | 1.10.3.1.7 | Concreto Clase D 1(f'c=210 kg/cm2 bajo agua) | milestone | 0d | 2013-12-01 | 2013-12-01 |  | 656d |  | start no earlier than 2013-12-01 | LLAMA COCHABAMBA | 610.D.1 |
| 205 | 1.10.3.1.8 | Concreto Clase D2 (f'c=210 kg/cm2 bajo agua) - Adic. N° 08 |  | 31d | 2013-12-01 | 2013-12-31 | 207FS-31d | 291d | 0d |  |  |  |
| 206 | 1.10.3.1.9 | Concreto Clase H (f'c=100 kg/cm2) | milestone | 0d | 2013-12-01 | 2013-12-01 |  | 656d |  | start no earlier than 2013-12-01 | LLAMA COCHABAMBA | 610.H |
| 207 | 1.10.3.1.10 | Concreto Clase H2 (f'c=100 kg/cm2) - Adic. N° 08 |  | 31d | 2013-12-01 | 2013-12-31 | 199FS-121d | 291d | 0d |  |  |  |
| 208 | 1.10.3.1.11 | Encofrado y desencofrado en seco |  | 31d | 2013-12-01 | 2013-12-31 | 207FS-31d | 291d | 0d | start no earlier than 2013-09-01 | LLAMA COCHABAMBA | 612.A |
| 209 | 1.10.3.1.12 | Encofrado y desencofrado bajo agua |  | 31d | 2013-12-01 | 2013-12-31 | 208FF | 291d | 0d | start no earlier than 2012-08-01 | LLAMA COCHABAMBA | 612.B |
| 210 | 1.10.3.1.13 | Encofrado y desencofrado caravista |  | 31d | 2013-12-01 | 2013-12-31 | 209SS, 211FF | 291d | 0d | start no earlier than 2013-09-01 | LLAMA COCHABAMBA | 612.C |
| 211 | 1.10.3.1.14 | Acero de refuerzo Fy= 4200 kg/cm2 |  | 31d | 2013-12-01 | 2013-12-31 | 207FS-31d | 291d | 0d | start no earlier than 2013-09-01 | LLAMA COCHABAMBA | 615 |
| 212 | 1.10.3.1.15 | Transporte de material excedente a DME para D < = 1km |  | 92d | 2013-09-01 | 2014-03-31 | 199SS | 456d | 0d | start no earlier than 2012-08-01 | LLAMA COCHABAMBA | 700.G |
| 213 | 1.10.3.1.16 | Transporte de material excedente a DME para D > 1km |  | 92d | 2013-09-01 | 2014-03-31 | 212SS | 456d |  | start no earlier than 2012-08-01 | LLAMA COCHABAMBA | 700.H |
| 214 | 1.10.3.2 | **SUPERESTRUCTURA** |  | 28d | 2014-02-01 | 2014-02-28 |  | 291d |  |  | LLAMA COCHABAMBA | 8.02 |
| 215 | 1.10.3.2.1 | Concreto Clase C (f'c=280 kg/cm2) | milestone | 0d | 2014-02-01 | 2014-02-01 |  | 594d |  | start no earlier than 2014-02-01 | LLAMA COCHABAMBA | 610.C |
| 216 | 1.10.3.2.2 | Concreto Clase C (f'c=280 kg/cm2) - Adic. N° 08 |  | 28d | 2014-02-01 | 2014-02-28 | 219SS | 291d | 0d | start no earlier than 2014-02-01 |  |  |
| 217 | 1.10.3.2.3 | Concreto Clase D (f'c=210 kg/cm2) | milestone | 0d | 2014-02-01 | 2014-02-01 |  | 594d |  | start no earlier than 2014-02-01 | LLAMA COCHABAMBA | 610.D |
| 218 | 1.10.3.2.4 | Concreto Clase D (f'c=210 kg/cm2) - Adic. N° 08 |  | 28d | 2014-02-01 | 2014-02-28 | 219FF, 216FS-59d | 566d | 182d | start no earlier than 2014-02-01 |  |  |
| 219 | 1.10.3.2.5 | Encofrado y desencofrado en seco |  | 28d | 2014-02-01 | 2014-02-28 | 220FF | 291d | 0d | start no earlier than 2014-02-01 | LLAMA COCHABAMBA | 612.A |
| 220 | 1.10.3.2.6 | Acero de refuerzo Fy= 4200 kg/cm2 |  | 28d | 2014-02-01 | 2014-02-28 | 221FS-28d | 291d | 0d | start no earlier than 2014-02-01 | LLAMA COCHABAMBA | 615 |
| 221 | 1.10.3.2.7 | Falso puente |  | 28d | 2014-02-01 | 2014-02-28 | 203FS+31d | 291d | 0d | start no earlier than 2014-02-01 | LLAMA COCHABAMBA | 616 |

| ID | WBS | Task | Type | Duration | Start | Finish | Predecessors | Total slack | Free slack | Constraint | Calendar | Text1 |
| --- | --- | --- | --- | --- | --- | --- | --- | --- | --- | --- | --- | --- |
| 222 | 1.10.3.3 | **OBRAS DE PROTECCION** |  | 31d | 2014-03-01 | 2014-03-31 |  | 535d |  |  | LLAMA COCHABAMBA | 8.03 |
| 223 | 1.10.3.3.1 | Perfilado y compactado para enrocado |  | 31d | 2014-03-01 | 2014-03-31 | 199FS-31d | 535d | 0d | start no earlier than 2014-03-01 | LLAMA COCHABAMBA | 207.B |
| 224 | 1.10.3.3.2 | Filtro Drenante | milestone | 0d | 2014-03-01 | 2014-03-01 |  | 566d |  | start no earlier than 2014-03-01 |  |  |
| 225 | 1.10.3.3.3 | Filtro drenante - Adic. N° 08 |  | 31d | 2014-03-01 | 2014-03-31 | 223FF | 535d | 0d | start no earlier than 2014-03-01 | LLAMA COCHABAMBA | 647 |
| 226 | 1.10.3.3.4 | Enrocado |  | 31d | 2014-03-01 | 2014-03-31 | 225SS, 223FS-59d | 535d |  | start no earlier than 2014-03-01 | LLAMA COCHABAMBA | 666 |
| 227 | 1.10.3.4 | **VARIOS** |  | 303d | 2014-02-01 | 2014-11-30 |  | 291d |  |  | LLAMA COCHABAMBA | 8.04 |
| 228 | 1.10.3.4.1 | Acabado de veredas |  | 28d | 2014-02-01 | 2014-02-28 | 216FS-28d | 413d | 0d | start no earlier than 2012-10-01 | LLAMA COCHABAMBA | 611.A |
| 229 | 1.10.3.4.2 | Bruñas rompe aguas |  | 28d | 2014-02-01 | 2014-02-28 | 228FF | 413d | 0d | start no earlier than 2012-10-01 | LLAMA COCHABAMBA | 611.B |
| 230 | 1.10.3.4.3 | Baranda metalica (incluye fabricacion y pintura) |  | 31d | 2014-07-01 | 2014-07-31 | 229FF+153d | 413d | 0d | start no earlier than 2012-10-01 | LLAMA COCHABAMBA | 615.C |
| 231 | 1.10.3.4.4 | Tubo de PVC-SAP, D=3 " x pieza |  | 28d | 2014-02-01 | 2014-02-28 | 221FS-28d | 566d | 0d | start no earlier than 2013-10-01 | LLAMA COCHABAMBA | 649.B |
| 232 | 1.10.3.4.5 | Tubo de PVC-SAP, D=6 " |  | 28d | 2014-02-01 | 2014-02-28 | 231FF | 566d | 0d | start no earlier than 2012-10-01 | LLAMA COCHABAMBA | 619.E.1 |
| 233 | 1.10.3.4.6 | Fabricación y colocación de juntas de dilatación |  | 28d | 2014-02-01 | 2014-02-28 | 232FF | 566d | 0d | start no earlier than 2012-10-01 | LLAMA COCHABAMBA | 659 |
| 234 | 1.10.3.4.7 | Apoyo de Neopreno (30x35x10) cm |  | 28d | 2014-02-01 | 2014-02-28 | 233FF | 566d |  | start no earlier than 2012-10-01 | LLAMA COCHABAMBA | 680.B |
| 235 | 1.10.3.4.8 | Guardavia Metálica |  | 31d | 2014-07-01 | 2014-07-31 | 230FF | 413d | 0d | start no earlier than 2012-10-01 | LLAMA COCHABAMBA | 820.A |
| 236 | 1.10.3.4.9 | Pintados de parapetos en muros y alcantarillas |  | 30d | 2014-07-02 | 2014-07-31 | 235FF, 218FS-59d | 413d |  | start no earlier than 2012-10-01 | LLAMA COCHABAMBA | 840.A |
| 237 | 1.10.3.4.10 | Riego de Liga |  | 30d | 2014-11-01 | 2014-11-30 | 216FS+245d | 291d |  | start no earlier than 2012-10-01 | LLAMA COCHABAMBA | 841 |
| 238 | 1.10.4 | **PUENTE MAYGASBAMBA** |  | 304d | 2014-07-01 | 2015-04-30 |  | 140d |  |  | LLAMA COCHABAMBA | 9.00 |
| 239 | 1.10.4.1 | **SUBESTRUCTURA** |  | 184d | 2014-07-01 | 2014-12-31 |  | 140d |  |  | LLAMA COCHABAMBA | 8.01 |
| 240 | 1.10.4.1.1 | Excavacion no clasificada para estructuras en seco |  | 62d | 2014-07-01 | 2014-08-31 | 10SS+684d | 140d | 0d | start no earlier than 2013-04-01 | LLAMA COCHABAMBA | 601.B |
| 241 | 1.10.4.1.2 | Excavacion no clasificada para estructuras bajo agua |  | 62d | 2014-07-01 | 2014-08-31 | 240FF | 140d | 0d | start no earlier than 2013-04-01 | LLAMA COCHABAMBA | 601.C |
| 242 | 1.10.4.1.3 | Relleno para estructuras con material de prestamo |  | 92d | 2014-10-01 | 2014-12-31 | 244 | 260d | 0d | start no earlier than 2013-06-01 | LLAMA COCHABAMBA | 605.A |
| 243 | 1.10.4.1.4 | Relleno para estructuras con material propio |  | 92d | 2014-10-01 | 2014-12-31 | 242FF | 260d |  | start no earlier than 2013-05-01 | LLAMA COCHABAMBA | 605.B |
| 244 | 1.10.4.1.5 | Concreto Clase D (f'c=210 kg/cm2) |  | 92d | 2014-07-01 | 2014-09-30 | 245FS-92d, 249FS-92d | 140d | 0d | start no earlier than 2013-04-01 | LLAMA COCHABAMBA | 610.D |
| 245 | 1.10.4.1.6 | Concreto Clase D 1(f'c=210 kg/cm2 bajo agua) |  | 92d | 2014-07-01 | 2014-09-30 | 246FS-92d | 140d | 0d | start no earlier than 2013-04-01 | LLAMA COCHABAMBA | 610.D.1 |
| 246 | 1.10.4.1.7 | Concreto Clase H 1(f'c=140 kg/cm2+ 30%PM) |  | 92d | 2014-07-01 | 2014-09-30 | 241FS-62d | 140d | 0d | start no earlier than 2013-04-01 | LLAMA COCHABAMBA | 610.H.1 |
| 247 | 1.10.4.1.8 | Encofrado y desencofrado en seco |  | 92d | 2014-07-01 | 2014-09-30 | 246FS-92d | 140d | 0d | start no earlier than 2013-04-01 | LLAMA COCHABAMBA | 612.A |
| 248 | 1.10.4.1.9 | Encofrado y desencofrado bajo agua |  | 92d | 2014-07-01 | 2014-09-30 | 247FF | 140d | 0d | start no earlier than 2013-04-01 | LLAMA COCHABAMBA | 612.B |
| 249 | 1.10.4.1.10 | Encofrado y desencofrado caravista |  | 92d | 2014-07-01 | 2014-09-30 | 248FF, 250FF | 140d | 0d | start no earlier than 2013-04-01 | LLAMA COCHABAMBA | 612.C |
| 250 | 1.10.4.1.11 | Acero de refuerzo Fy= 4200 kg/cm2 |  | 92d | 2014-07-01 | 2014-09-30 | 246FS-92d | 140d | 0d | start no earlier than 2013-04-01 | LLAMA COCHABAMBA | 615 |
| 251 | 1.10.4.1.12 | Transporte de material excedente a DME para D < = 1km |  | 62d | 2014-07-01 | 2014-08-31 | 241SS | 303d | 0d | start no earlier than 2013-04-01 | LLAMA COCHABAMBA | 700.G |
| 252 | 1.10.4.1.13 | Transporte de material excedente a DME para D > 1km |  | 62d | 2014-07-01 | 2014-08-31 | 251SS | 303d |  | start no earlier than 2013-04-01 | LLAMA COCHABAMBA | 700.H |

| ID | WBS | Task | Duration | Start | Finish | Predecessors | Total slack | Free slack | Constraint | Calendar | Text1 |
| --- | --- | --- | --- | --- | --- | --- | --- | --- | --- | --- | --- |
| 253 | 1.10.4.2 | **SUPERESTRUCTURA** | 122d | 2014-08-01 | 2014-11-30 |  | 140d |  |  | LLAMA COCHABAMBA | 8.02 |
| 254 | 1.10.4.2.1 | Concreto Clase C (f'c=280 kg/cm2) | 122d | 2014-08-01 | 2014-11-30 | 256SS | 140d | 0d | start no earlier than 2013-06-01 | LLAMA COCHABAMBA | 610.C |
| 255 | 1.10.4.2.2 | Concreto Clase D (f'c=210 kg/cm2) | 122d | 2014-08-01 | 2014-11-30 | 256FF, 254FS-123d | 291d | 31d | start no earlier than 2013-05-01 | LLAMA COCHABAMBA | 610.D |
| 256 | 1.10.4.2.3 | Encofrado y desencofrado en seco | 122d | 2014-08-01 | 2014-11-30 | 258FF, 244FS-62d, 260FF+61d | 140d | 0d | start no earlier than 2013-06-01 | LLAMA COCHABAMBA | 612.A |
| 257 | 1.10.4.2.4 | Fabricación de estructura metalica c/acero grado 36 | 61d | 2014-08-01 | 2014-09-30 | 2SS | 140d | 0d | start no earlier than 2014-08-01 | LLAMA COCHABAMBA | 616.A |
| 258 | 1.10.4.2.5 | Acero de refuerzo Fy= 4200 kg/cm2 | 122d | 2014-08-01 | 2014-11-30 | 244FS-61d | 140d | 0d | start no earlier than 2013-08-01 | LLAMA COCHABAMBA | 615 |
| 259 | 1.10.4.2.6 | Transporte de estructura metalica, herramientas y equipos de montaje | 61d | 2014-08-01 | 2014-09-30 | 257FS-61d | 140d | 0d | start no earlier than 2013-05-01 | LLAMA COCHABAMBA | 616.B |
| 260 | 1.10.4.2.7 | Montaje y lanzamiento de estructura | 61d | 2014-08-01 | 2014-09-30 | 259FS-61d | 140d | 0d | start no earlier than 2013-05-01 | LLAMA COCHABAMBA | 616.C |
| 261 | 1.10.4.2.8 | Pintura de estructura metalica | 61d | 2014-08-01 | 2014-09-30 | 260FS-61d | 352d |  | start no earlier than 2013-06-01 | LLAMA COCHABAMBA | 616.D |
| 262 | 1.10.4.3 | **OBRAS DE PROTECCION** | 92d | 2014-10-01 | 2014-12-31 |  | 260d |  |  | LLAMA COCHABAMBA | 8.03 |
| 263 | 1.10.4.3.1 | Perfilado y compactado para enrocado | 92d | 2014-10-01 | 2014-12-31 | 241FS+30d | 260d | 0d | start no earlier than 2013-06-01 | LLAMA COCHABAMBA | 207.B |
| 264 | 1.10.4.3.2 | Filtro drenante | 92d | 2014-10-01 | 2014-12-31 | 263FF | 260d | 0d | start no earlier than 2013-06-01 | LLAMA COCHABAMBA | 647 |
| 265 | 1.10.4.3.3 | Enrocado | 92d | 2014-10-01 | 2014-12-31 | 264SS, 263FS-92d | 260d |  | start no earlier than 2013-06-01 | LLAMA COCHABAMBA | 666 |
| 266 | 1.10.4.4 | **VARIOS** | 273d | 2014-08-01 | 2015-04-30 |  | 140d |  |  | LLAMA COCHABAMBA | 8.04 |
| 267 | 1.10.4.4.1 | Acabado de veredas | 92d | 2014-10-01 | 2014-12-31 | 254FS-61d | 260d | 0d | start no earlier than 2013-06-01 | LLAMA COCHABAMBA | 611.A |
| 268 | 1.10.4.4.2 | Bruñas rompe aguas | 92d | 2014-10-01 | 2014-12-31 | 267FF | 260d | 0d | start no earlier than 2013-06-01 | LLAMA COCHABAMBA | 611.B |
| 269 | 1.10.4.4.3 | Baranda metalica (incluye fabricacion y pintura) | 92d | 2014-10-01 | 2014-12-31 | 268FF | 260d | 0d | start no earlier than 2013-06-01 | LLAMA COCHABAMBA | 615.C |
| 270 | 1.10.4.4.4 | Tubo de PVC-SAP, D=3 " x pieza | 61d | 2014-08-01 | 2014-09-30 | 260FS-61d | 352d | 0d | start no earlier than 2013-06-01 | LLAMA COCHABAMBA | 649.B |
| 271 | 1.10.4.4.5 | Tubo de PVC-SAP, D=6 " | 61d | 2014-08-01 | 2014-09-30 | 270FF | 352d | 0d | start no earlier than 2013-06-01 | LLAMA COCHABAMBA | 619.E.1 |
| 272 | 1.10.4.4.6 | Fabricación y colocación de juntas de dilatación | 61d | 2014-08-01 | 2014-09-30 | 271FF | 352d | 0d | start no earlier than 2013-06-01 | LLAMA COCHABAMBA | 659 |
| 273 | 1.10.4.4.7 | Dispositivo de apoyo (45x45x14) cm | 61d | 2014-08-01 | 2014-09-30 | 272FF | 352d |  | start no earlier than 2013-06-01 | LLAMA COCHABAMBA | 680.D |
| 274 | 1.10.4.4.8 | Guardavia Metálica | 92d | 2014-10-01 | 2014-12-31 | 269FF | 260d | 0d | start no earlier than 2013-06-01 | LLAMA COCHABAMBA | 820.A |
| 275 | 1.10.4.4.9 | Pintados de parapetos en muros y alcantarillas | 92d | 2014-10-01 | 2014-12-31 | 274FF, 255FS-92d | 260d |  | start no earlier than 2013-06-01 | LLAMA COCHABAMBA | 840.A |
| 276 | 1.10.4.4.10 | Riego de Liga | 30d | 2015-04-01 | 2015-04-30 | 254FS+121d | 140d |  | start no earlier than 2013-06-01 | LLAMA COCHABAMBA | 841 |

| ID | WBS | Task | Type | Duration | Start | Finish | Predecessors | Total slack | Free slack | Constraint | Calendar | Text1 |
| --- | --- | --- | --- | --- | --- | --- | --- | --- | --- | --- | --- | --- |
| 277 | 1.10.5 | **PUENTE HUALGAYOC** |  | 791d | 2012-10-01 | 2014-11-30 |  | 291d |  |  | LLAMA COCHABAMBA | 10.00 |
| 278 | 1.10.5.1 | **SUBESTRUCTURA** |  | 669d | 2012-10-01 | 2014-07-31 |  | 323d |  |  | LLAMA COCHABAMBA | 8.01 |
| 279 | 1.10.5.1.1 | Excavacion no clasificada para estructuras en seco |  | 31d | 2012-10-01 | 2012-10-31 | 10SS+46d | 912d | 578d | start no earlier than 2012-10-01 | LLAMA COCHABAMBA | 601.B |
| 280 | 1.10.5.1.2 | Excavacion no clasificada para estructuras bajo agua |  | 223d | 2012-10-01 | 2014-07-31 | 279FF+60d | 334d | 0d | start no earlier than 2012-10-01 | LLAMA COCHABAMBA | 601.C |
| 281 | 1.10.5.1.3 | Relleno para estructuras con material de prestamo |  | 120d | 2012-11-01 | 2013-02-28 | 283FS-92d | 931d | 92d | start no earlier than 2012-11-01 | LLAMA COCHABAMBA | 605.A |
| 282 | 1.10.5.1.4 | Relleno para estructuras con material propio |  | 28d | 2013-02-01 | 2013-02-28 | 281SS | 931d |  | start no earlier than 2013-02-01 | LLAMA COCHABAMBA | 605.B |
| 283 | 1.10.5.1.5 | Concreto Clase D (f'c=210 kg/cm2) |  | 61d | 2012-11-01 | 2012-12-31 | 284FS-30d, 288FS-61d | 292d | 0d | start no earlier than 2012-11-01 | LLAMA COCHABAMBA | 610.D |
| 284 | 1.10.5.1.6 | Concreto Clase D 1(f'c=210 kg/cm2 bajo agua) |  | 30d | 2012-11-01 | 2012-11-30 |  | 292d | 0d | start no earlier than 2012-11-01 | LLAMA COCHABAMBA | 610.D.1 |
| 285 | 1.10.5.1.7 | Concreto Clase H (f'c=100 kg/cm2) | milestone | 0d | 2012-10-01 | 2012-10-01 |  | 1082d |  | start no earlier than 2012-10-01 | LLAMA COCHABAMBA | 610.H |
| 286 | 1.10.5.1.8 | Encofrado y desencofrado en seco |  | 120d | 2012-11-01 | 2013-02-28 |  | 323d | 0d | start no earlier than 2012-11-01 | LLAMA COCHABAMBA | 612.A |
| 287 | 1.10.5.1.9 | Encofrado y desencofrado bajo agua |  | 30d | 2012-11-01 | 2012-11-30 | 286FF-90d | 323d | 31d | start no earlier than 2012-11-01 | LLAMA COCHABAMBA | 612.B |
| 288 | 1.10.5.1.10 | Encofrado y desencofrado caravista |  | 61d | 2012-11-01 | 2012-12-31 | 287FF, 289FF | 292d | 0d | start no earlier than 2012-11-01 | LLAMA COCHABAMBA | 612.C |
| 289 | 1.10.5.1.11 | Acero de refuerzo Fy= 4200 kg/cm2 |  | 61d | 2012-11-01 | 2012-12-31 |  | 292d | 0d | start no earlier than 2012-11-01 | LLAMA COCHABAMBA | 615 |
| 290 | 1.10.5.1.12 | Transporte de material excedente a DME para D < = 1km |  | 223d | 2012-10-01 | 2014-07-31 | 280SS | 334d | 0d | start no earlier than 2012-10-01 | LLAMA COCHABAMBA | 700.G |
| 291 | 1.10.5.1.13 | Transporte de material excedente a DME para D > 1km |  | 223d | 2012-10-01 | 2014-07-31 | 290SS | 334d |  | start no earlier than 2012-10-01 | LLAMA COCHABAMBA | 700.H |
| 292 | 1.10.5.2 | **SUPERESTRUCTURA** |  | 151d | 2012-11-01 | 2013-03-31 |  | 382d |  |  | LLAMA COCHABAMBA | 8.02 |
| 293 | 1.10.5.2.1 | Concreto Clase C (f'c=280 kg/cm2) |  | 31d | 2013-03-01 | 2013-03-31 | 295SS | 291d | 0d | start no earlier than 2013-03-01 | LLAMA COCHABAMBA | 610.C |
| 294 | 1.10.5.2.2 | Concreto Clase D (f'c=210 kg/cm2) |  | 31d | 2013-03-01 | 2013-03-31 | 293FS-61d, 295FF | 900d |  | start no earlier than 2013-03-01 | LLAMA COCHABAMBA | 610.D |
| 295 | 1.10.5.2.3 | Encofrado y desencofrado en seco |  | 59d | 2013-02-01 | 2013-03-31 | 283FS-31d, 300FF+27d, 296FF | 319d | 0d | start no earlier than 2013-02-01 | LLAMA COCHABAMBA | 612.A |
| 296 | 1.10.5.2.4 | Acero de refuerzo Fy= 4200 kg/cm2 |  | 28d | 2013-02-01 | 2013-02-28 | 283FS+31d | 292d | 1d | start no earlier than 2013-02-01 | LLAMA COCHABAMBA | 615 |
| 297 | 1.10.5.2.5 | Fabricación de estructura metalica c/acero grado 50 |  | 30d | 2012-11-01 | 2012-11-30 | 296SF-63d, 2 | 382d | 0d | start no earlier than 2012-11-01 | LLAMA COCHABAMBA | 616.A1 |
| 298 | 1.10.5.2.6 | Fabricación de estructura metalica c/acero grado 36 |  | 30d | 2012-11-01 | 2012-11-30 | 297FF | 382d | 0d | start no earlier than 2012-11-01 | LLAMA COCHABAMBA | 616.A2 |
| 299 | 1.10.5.2.7 | Transporte de estructura metalica, herramientas y equipos de montaje |  | 31d | 2012-12-01 | 2012-12-31 | 298 | 382d | 0d | start no earlier than 2012-12-01 | LLAMA COCHABAMBA | 616.B |
| 300 | 1.10.5.2.8 | Montaje y lanzamiento de estructura |  | 31d | 2012-12-01 | 2012-12-31 | 299FS-31d | 382d | 0d | start no earlier than 2012-12-01 | LLAMA COCHABAMBA | 616.C |
| 301 | 1.10.5.2.9 | Pintura de estructura metalica |  | 31d | 2012-12-01 | 2012-12-31 | 300FS-31d | 990d |  | start no earlier than 2012-12-01 | LLAMA COCHABAMBA | 616.D |

| ID | WBS | Task | Duration | Start | Finish | Predecessors | Total slack | Free slack | Constraint | Calendar | Text1 |
| --- | --- | --- | --- | --- | --- | --- | --- | --- | --- | --- | --- |
| 302 | 1.10.5.3 | **OBRAS DE PROTECCION** | 546d | 2013-02-01 | 2014-07-31 |  | 413d |  |  | LLAMA COCHABAMBA | 8.03 |
| 303 | 1.10.5.3.1 | Perfilado y compactado para enrocado | 59d | 2013-02-01 | 2014-05-31 | 280FS-546d | 474d | 61d | start no earlier than 2013-02-01 | LLAMA COCHABAMBA | 207.B |
| 304 | 1.10.5.3.2 | Filtro drenante | 90d | 2013-02-01 | 2014-07-31 | 303FF | 413d | 0d | start no earlier than 2013-02-01 | LLAMA COCHABAMBA | 647 |
| 305 | 1.10.5.3.3 | Enrocado | 59d | 2013-02-01 | 2014-05-31 | 304SS, 303FS-546d | 474d |  | start no earlier than 2013-02-01 | LLAMA COCHABAMBA | 666 |
| 306 | 1.10.5.4 | **VARIOS** | 730d | 2012-12-01 | 2014-11-30 |  | 291d |  |  | LLAMA COCHABAMBA | 8.04 |
| 307 | 1.10.5.4.1 | Demolición de estructuras de concreto | 62d | 2014-05-01 | 2014-07-31 | 280FS-92d | 413d |  | start no earlier than 2014-05-01 | LLAMA COCHABAMBA | 645 |
| 308 | 1.10.5.4.2 | Acabado de veredas | 31d | 2013-03-01 | 2013-03-31 | 293FS-31d | 413d | 0d | start no earlier than 2013-03-01 | LLAMA COCHABAMBA | 611.A |
| 309 | 1.10.5.4.3 | Bruñas rompe aguas | 31d | 2013-03-01 | 2013-03-31 | 308FF | 413d | 0d | start no earlier than 2013-03-01 | LLAMA COCHABAMBA | 611.B |
| 310 | 1.10.5.4.4 | Baranda metalica (incluye fabricacion y pintura) | 31d | 2013-03-01 | 2013-03-31 | 309FF | 413d | 0d | start no earlier than 2013-03-01 | LLAMA COCHABAMBA | 615.C |
| 311 | 1.10.5.4.5 | Tubo de PVC-SAP, D=3 " x pieza | 31d | 2013-03-01 | 2013-03-31 | 300FS-60d | 900d | 0d | start no earlier than 2013-03-01 | LLAMA COCHABAMBA | 649.B |
| 312 | 1.10.5.4.6 | Tubo de PVC-SAP, D=6 " | 31d | 2013-03-01 | 2013-03-31 | 311FF | 900d | 0d | start no earlier than 2013-03-01 | LLAMA COCHABAMBA | 619.E.1 |
| 313 | 1.10.5.4.7 | Fabricación y colocación de juntas de dilatación | 31d | 2013-03-01 | 2013-03-31 | 312FF | 900d | 0d | start no earlier than 2013-03-01 | LLAMA COCHABAMBA | 659 |
| 314 | 1.10.5.4.8 | Dispositivo de apoyo (30x35x9.2) cm | 31d | 2012-12-01 | 2012-12-31 | 313FF-90d | 990d |  | start no earlier than 2012-12-01 | LLAMA COCHABAMBA | 680.A |
| 315 | 1.10.5.4.9 | Guardavia Metálica | 31d | 2014-07-01 | 2014-07-31 | 310FF+487d | 413d | 0d | start no earlier than 2014-07-01 | LLAMA COCHABAMBA | 820.A |
| 316 | 1.10.5.4.10 | Pintados de parapetos en muros y alcantarillas | 31d | 2014-07-01 | 2014-07-31 | 315FF | 413d |  | start no earlier than 2014-07-01 | LLAMA COCHABAMBA | 840.A |
| 317 | 1.10.5.4.11 | Riego de Liga | 30d | 2014-11-01 | 2014-11-30 | 293FS+579d | 291d |  | start no earlier than 2014-11-01 | LLAMA COCHABAMBA | 841 |
| 318 | 1.11 | **REUBICACION DE ESTRUCTURAS** | 273d | 2013-11-01 | 2014-07-31 |  | 413d |  |  |  |  |
| 319 | 1.11.1 | **LINEAS Y REDES PRIMARIAS** | 243d | 2013-12-01 | 2014-07-31 |  | 413d |  |  |  |  |
| 320 | 1.11.1.1 | **MONTAJE Y DESMONTAJE ELECTROMECANICO** | 243d | 2013-12-01 | 2014-07-31 |  | 413d |  |  |  |  |
| 321 | 1.11.1.1.1 | **OBRAS PRELIMINARES** | 243d | 2013-12-01 | 2014-07-31 |  | 413d |  |  |  |  |
| 322 | 1.11.1.1.1.1 | Reaplanteo Topografico y ubicación de Estructuras | 243d | 2013-12-01 | 2014-07-31 | 2FS+567d | 413d | 0d |  |  |  |
| 323 | 1.11.1.1.2 | **INSTALACION DE POSTES DE CONCRETO Y MADERA** | 243d | 2013-12-01 | 2014-07-31 |  | 413d |  |  |  |  |
| 324 | 1.11.1.1.2.1 | Instalacion y Montaje de postes de concreto armado | 243d | 2013-12-01 | 2014-07-31 | 322FS-243d, 337FF, 338FF, 340FF | 413d | 0d |  |  |  |
| 325 | 1.11.1.1.3 | **INSTALACION DE RETENIDAS** | 243d | 2013-12-01 | 2014-07-31 |  | 413d |  |  |  |  |
| 326 | 1.11.1.1.3.1 | Instalacion y montaje de retenidas | 243d | 2013-12-01 | 2014-07-31 | 324FS-243d | 413d | 0d |  |  |  |

| ID | WBS | Task | Duration | Start | Finish | Predecessors | Total slack | Free slack |
| --- | --- | --- | --- | --- | --- | --- | --- | --- |
| 327 | 1.11.1.1.4 | **MONTAJE DE ARMADOS** | 243d | 2013-12-01 | 2014-07-31 |  | 413d |  |
| 328 | 1.11.1.1.4.1 | Instalacion y montaje de Armados | 243d | 2013-12-01 | 2014-07-31 | 326FS-243d | 413d | 0d |
| 329 | 1.11.1.1.5 | **MONTAJE DE CONDUCTORES** | 243d | 2013-12-01 | 2014-07-31 |  | 413d |  |
| 330 | 1.11.1.1.5.1 | Tendido y puesta en flecha de conductor AAAC 50 MM2 | 243d | 2013-12-01 | 2014-07-31 | 328FS-243d | 413d | 0d |
| 331 | 1.11.1.1.5.2 | Tendido y puesta en flecha de conductor AAAC 120 MM2 | 31d | 2014-07-01 | 2014-07-31 | 328FS-31d | 413d | 0d |
| 332 | 1.11.1.1.6 | **INSTALACION DE PUESTA A TIERRA** | 243d | 2013-12-01 | 2014-07-31 |  | 413d |  |
| 333 | 1.11.1.1.6.1 | Instalacion y montaje de puestas a tierra | 243d | 2013-12-01 | 2014-07-31 | 330FS-243d, 331FS-243d | 413d | 0d |
| 334 | 1.11.1.1.7 | **PRUEBAS Y PUESTA EN SERVICIO** | 243d | 2013-12-01 | 2014-07-31 |  | 413d |  |
| 335 | 1.11.1.1.7.1 | Prueba y puesta en servicio de lineas y redes primarias | 243d | 2013-12-01 | 2014-07-31 | 333FS-243d | 413d |  |
| 336 | 1.11.1.1.8 | **DESMONTAJE DE LINEAS Y REDES PRIMARIAS** | 243d | 2013-12-01 | 2014-07-31 |  | 413d |  |
| 337 | 1.11.1.1.8.1 | Desmontaje de lineas y postes de madera | 243d | 2013-12-01 | 2014-07-31 | 322SS | 413d | 0d |
| 338 | 1.11.1.1.8.2 | Desmontaje de lineas y postes de concreto | 243d | 2013-12-01 | 2014-07-31 | 322SS | 413d | 0d |
| 339 | 1.11.1.1.9 | **SUMINSTRO DE MATERIALES Y ACCESORIOS** | 243d | 2013-12-01 | 2014-07-31 |  | 413d |  |
| 340 | 1.11.1.1.9.1 | Suministro de materiales y accesorios para lineas primarias | 243d | 2013-12-01 | 2014-07-31 | 322SS | 413d | 0d |
| 341 | 1.11.2 | **REDES SECUNDARIAS** | 273d | 2013-11-01 | 2014-07-31 |  | 413d |  |
| 342 | 1.11.2.1 | **MONTAJE Y DESMONTAJE ELECTROMECANICO** | 273d | 2013-11-01 | 2014-07-31 |  | 413d |  |
| 343 | 1.11.2.1.1 | **OBRAS PRELIMINARES** | 273d | 2013-11-01 | 2014-07-31 |  | 413d |  |
| 344 | 1.11.2.1.1.1 | Reaplanteo Topografico y ubicación de Estructuras (RS) | 273d | 2013-11-01 | 2014-07-31 | 322SS-30d | 413d | 0d |
| 345 | 1.11.2.1.2 | **INSTALACION DE POSTES DE CONCRETO Y MADERA** | 273d | 2013-11-01 | 2014-07-31 |  | 413d |  |
| 346 | 1.11.2.1.2.1 | Instalacion y Montaje de postes de madera (RS) | 273d | 2013-11-01 | 2014-07-31 | 344FS-273d, 365FF | 413d | 0d |
| 347 | 1.11.2.1.2.2 | Instalacion y Montaje de postes de concreto armado (RS) | 273d | 2013-11-01 | 2014-07-31 | 344FS-273d, 365FF | 413d | 0d |
| 348 | 1.11.2.1.3 | **INSTALACION DE RETENIDAS** | 273d | 2013-11-01 | 2014-07-31 |  | 413d |  |
| 349 | 1.11.2.1.3.1 | Instalación de retenida inclinada (R.S) | 273d | 2013-11-01 | 2014-07-31 | 346FS-273d, 347FS-273d | 413d | 0d |
| 350 | 1.11.2.1.3.2 | Instalación de retenida vertical (R.S) | 273d | 2013-11-01 | 2014-07-31 | 346FS-273d, 347FS-273d | 413d | 0d |

| ID | WBS | Task | Type | Duration | Start | Finish | Predecessors | Total slack | Free slack | Constraint | Calendar |
| --- | --- | --- | --- | --- | --- | --- | --- | --- | --- | --- | --- |
| 351 | 1.11.2.1.4 | **MONTAJE DE ARMADOS** |  | 273d | 2013-11-01 | 2014-07-31 |  | 413d |  |  |  |
| 352 | 1.11.2.1.4.1 | Instalacion y montaje de Armados (RS) |  | 273d | 2013-11-01 | 2014-07-31 | 349FS-273d, 350FS-273d | 413d | 0d |  |  |
| 353 | 1.11.2.1.5 | **MONTAJE DE CONDUCTORES AUTOPORTANTES** |  | 273d | 2013-11-01 | 2014-07-31 |  | 413d |  |  |  |
| 354 | 1.11.2.1.5.1 | Instalación y montaje de conductores autoportantes (R.S.) |  | 273d | 2013-11-01 | 2014-07-31 | 352FS-273d | 413d | 0d |  |  |
| 355 | 1.11.2.1.6 | **INSTALACION DE PUESTA A TIERRA** |  | 273d | 2013-11-01 | 2014-07-31 |  | 413d |  |  |  |
| 356 | 1.11.2.1.6.1 | Inst. y conex. de PAT-1, P/ Puesta a tierra, c/ un electrodo, en poste de madera |  | 273d | 2013-11-01 | 2014-07-31 | 354SS | 413d | 0d |  |  |
| 357 | 1.11.2.1.6.2 | Inst. y conex. de PAT-1, P/ puesta a tierra, c/ un eletrodo, en poste de CAC |  | 151d | 2013-11-01 | 2014-03-31 | 354SS | 413d | 0d |  |  |
| 358 | 1.11.2.1.7 | **PASTORALES, LUMINARIAS Y LAMPARAS** |  | 273d | 2013-11-01 | 2014-07-31 |  | 413d |  |  |  |
| 359 | 1.11.2.1.7.1 | Instalacion y montaje de pastorales, luminarias y lamparas (RS) |  | 273d | 2013-11-01 | 2014-07-31 | 354SS | 413d | 0d |  |  |
| 360 | 1.11.2.1.8 | **CONEXIONES DOMICILIARIAS** |  | 273d | 2013-11-01 | 2014-07-31 |  | 413d |  |  |  |
| 361 | 1.11.2.1.8.1 | Instalacion y montaje de conexiones domiciliarias |  | 273d | 2013-11-01 | 2014-07-31 | 354SS | 413d | 0d |  |  |
| 362 | 1.11.2.1.9 | **PRUEBAS Y PUESTA EN SERVICIO** |  | 273d | 2013-11-01 | 2014-07-31 |  | 413d |  |  |  |
| 363 | 1.11.2.1.9.1 | Prueba y puesta a servicio (R.S.) |  | 273d | 2013-11-01 | 2014-07-31 | 361FS-273d, 359FS-273d, 357FS-151d, 356FS-273d, 354FS-273d | 413d |  |  |  |
| 364 | 1.11.2.1.10 | **DESMONTAJE DE INSTALACIONES EXISTENTES** |  | 273d | 2013-11-01 | 2014-07-31 |  | 413d |  |  |  |
| 365 | 1.11.2.1.10.1 | Desmontaje de redes secundarias en postes de madera (RS) |  | 273d | 2013-11-01 | 2014-07-31 | 344SS | 413d | 0d |  |  |
| 366 | 1.11.2.1.10.2 | Desmontaje de redes secundarias en postes de concreto (RS) |  | 273d | 2013-11-01 | 2014-07-31 | 344SS | 413d |  |  |  |
| 367 | 1.11.2.1.11 | **SUMINSTRO DE MATERIALES Y ACCESORIOS** |  | 273d | 2013-11-01 | 2014-07-31 |  | 413d |  |  |  |
| 368 | 1.11.2.1.11.1 | Suministro de materiales y accesorios para lineas secundarias |  | 273d | 2013-11-01 | 2014-07-31 | 344SS | 413d |  |  |  |
| 369 | 1.12 | FIN | milestone | 0d | 2015-09-17 | 2015-09-17 | 4FF, 6FF, 120FF, 140FF, 139FF, 128FF, 164FF, 27FF, 29FF, 31FF, 32FF, 25FF, 30FF, 20FF+33d, 22FF+17d, 130FF, 131FF, 132FF, 133FF+79d, 70FF, 102FF, 103FF, 134FF, 135FF, 136FF, 137FF, 261FF, 301FF, 194FF, 236FF, 161FF, 189FF, 226FF, 230FF, 265FF, 305FF, 275FF, 316FF, 62FF, 65FF, 97FF+48d, 95FF, 107FF, 105FF, 100FF+276d, 101FF+594d, 162FF, 191FF, 5FF, 7FF+367d, 143FF, 75FF, 13FF, 335FF, 363FF, 64FF, 69FF, 67FF, 72FF, 74FF+64d, 96FF, 99FF, 89FF, 368FF, 35FF+64d, 16FF, 37FF, 71FF, 108FF, 77FF, 86FF, 88FF, 198FF | 0d |  | start no earlier than 2015-01-22 | LLAMA COCHABAMBA |
